# TestBeam04

Schedule from MS Project, 2004-03-29 to 2004-07-15, A marks actual dates.
University of Florida Physics

## Calendars

- Standard: Mon-Fri 08:00-12:00, 13:00-17:00; Sat-Sun off. Exceptions (off unless hours are given): 2004-05-08 to 2004-05-09 08:00-12:00, 13:00-17:00, 2004-05-15 to 2004-05-16 08:00-12:00, 13:00-17:00, 2004-06-05 08:00-12:00, 13:00-17:00.

## Resources

| Resource |
| --- |
| Acosta |
| Geurts |
| Roberts |
| Stoeck |
| Gray |
| Scurlock |
| von der Mey |
| Gilmore |
| Madorsky |
| Tumanov |
| Zheng |
| Park |
| Golovtsv |
| Golovtsov |
| Uvarov |
| Wilkinson |
| Matveev |
| Joon |
| Gu |
| Holger |
| Case |
| Durkin |
| n/a |
| Lusin |
| Levchenko |
| Dubna |
| IHEP |
| Rice student |
| RPC |
| Korytov |
| Karjavine |
| Vorobyev |
| Y.Wook |
| Pakhotin |
| Kotov |
| K |
| Chertok |
| Vorobiev |
| Barashko |
| Trevino |
| Sytnik |
| Cox |

## Schedule

| ID | WBS | Task | Type | Duration | Start | Finish | Predecessors | Total slack | Free slack | Constraint | Resources | Work |
| --- | --- | --- | --- | --- | --- | --- | --- | --- | --- | --- | --- | --- |
| 1 | 1 | **People's Schedules** |  | 54d? | 2004-05-08 | 2004-07-15 |  | 0d |  |  |  | 3240h |
| 2 | 1.1 | Acosta 1 |  | 13d? | 2004-05-08 | 2004-05-20 |  | 41d |  | finish no earlier than 2004-05-20 | Acosta | 104h |
| 3 | 1.2 | Acosta 2 |  | 14d? | 2004-06-04 | 2004-06-22 |  | 17d |  | start no earlier than 2004-06-04 | Acosta | 112h |
| 4 | 1.3 | Barashko |  | 5d | 2004-05-24 | 2004-05-29 |  | 35d |  | finish no earlier than 2004-05-29 | Barashko | 40h |
| 5 | 1.4 | Chertok |  | 22d? | 2004-06-03 | 2004-07-01 |  | 10d |  | start no earlier than 2004-06-03 | Chertok | 176h |
| 6 | 1.5 | Geurts |  | 34d? | 2004-05-11 | 2004-06-22 |  | 17d |  | finish no earlier than 2004-06-22 | Geurts | 272h |
| 7 | 1.6 | Gilmore |  | 9d? | 2004-05-14 | 2004-05-24 |  | 39d |  | start no earlier than 2004-05-14 | Gilmore | 72h |
| 8 | 1.7 | Golovtsov |  | 9d? | 2004-05-15 | 2004-05-25 |  | 38d |  | finish no earlier than 2004-05-25 | Golovtsov | 72h |
| 9 | 1.8 | Gray |  | 32d? | 2004-05-08 | 2004-06-15 |  | 22d |  | finish no earlier than 2004-06-15 | Gray | 256h |
| 10 | 1.9 | Gu |  | 12d? | 2004-05-26 | 2004-06-09 |  | 26d |  | finish no earlier than 2004-06-09 | Gu | 96h |
| 11 | 1.10 | Joon |  | 15d? | 2004-06-01 | 2004-06-20 |  | 19d |  | finish no earlier than 2004-06-20 | Joon | 120h |
| 12 | 1.11 | Kotov |  | 47d? | 2004-05-15 | 2004-07-15 |  | 0d |  | start no earlier than 2004-05-15 | Kotov | 376h |
| 13 | 1.12 | Matveev |  | 6d? | 2004-06-11 | 2004-06-20 |  | 19d |  | finish no earlier than 2004-06-20 | Matveev | 48h |
| 14 | 1.13 | Pakhotin |  | 25d? | 2004-05-15 | 2004-06-15 |  | 22d |  | start no earlier than 2004-05-15 | Pakhotin | 200h |
| 15 | 1.14 | Roberts |  | 34d? | 2004-05-11 | 2004-06-22 |  | 17d |  | finish no earlier than 2004-06-22 | Roberts | 272h |
| 16 | 1.15 | Scurlock |  | 14d? | 2004-05-15 | 2004-06-01 |  | 33d |  | start no earlier than 2004-05-15 | Scurlock | 112h |
| 17 | 1.16 | Stoeck |  | 11d? | 2004-05-11 | 2004-05-21 |  | 40d |  | start no earlier than 2004-05-11 | Stoeck | 88h |
| 18 | 1.17 | Trevino |  | 34d? | 2004-05-11 | 2004-06-22 |  | 17d |  | start no earlier than 2004-05-11 | Trevino | 272h |
| 19 | 1.18 | Uvarov 1 |  | 9d? | 2004-05-15 | 2004-05-25 |  | 38d |  | finish no earlier than 2004-05-25 | Uvarov | 72h |
| 20 | 1.19 | Uvarov 2 |  | 8d? | 2004-06-05 | 2004-06-15 |  | 22d |  | finish no earlier than 2004-06-15 | Uvarov | 64h |
| 21 | 1.20 | Von der Mey 1 |  | 7d? | 2004-05-16 | 2004-05-24 |  | 39d |  | start no earlier than 2004-05-16 | von der Mey | 56h |
| 22 | 1.21 | Von der Mey 2 |  | 8d? | 2004-06-14 | 2004-06-23 |  | 16d |  | start no earlier than 2004-06-14 | von der Mey | 64h |
| 23 | 1.22 | Wilkinson |  | 9d? | 2004-05-17 | 2004-05-27 |  | 36d |  | finish no earlier than 2004-05-27 | Wilkinson | 72h |
| 24 | 1.23 | Karjavine |  | 28d? | 2004-05-17 | 2004-06-22 |  | 17d |  | finish no earlier than 2004-06-22 | Karjavine | 224h |
| 25 | 2 | Start Asynch beam | milestone | 0d | 2004-05-17 | 2004-05-17 |  | 27d | 0d | start no earlier than 2004-05-17 |  |  |
| 26 | 3 | Asynch, CSC-only |  | 7d? | 2004-05-17 | 2004-05-25 | 25 | 27d | 0d | start no earlier than 2004-05-17 |  |  |
| 27 | 4 | Asynch, CSC+tracker |  | 11d? | 2004-05-26 | 2004-06-08 | 26 | 27d |  | finish no earlier than 2004-06-08 |  |  |
| 28 | 5 | Start 25 ns beam | milestone | 0d | 2004-06-14 | 2004-06-14 |  | 18d | 0d | start no earlier than 2004-06-14 |  |  |
| 29 | 6 | Synch, CSC+tracker |  | 6d? | 2004-06-14 | 2004-06-21 | 28 | 18d |  | start no earlier than 2004-06-07 |  |  |

| ID | WBS | Task | Duration | Start | Finish | Complete | Remaining | Total slack | Constraint | Resources | Work | Actual work |
| --- | --- | --- | --- | --- | --- | --- | --- | --- | --- | --- | --- | --- |
| 30 | 7 | **Pre-beam Tasks** | 66d? | 2004-03-29 A | 2004-06-21 | 38% | 40.96d? | 18d |  |  | 6976h | 2550.4h |
| 31 | 7.1 | **New Periph Crate / FED crate software** | 40d? | 2004-03-29 A | 2004-05-17 | 35% | 26.12d? | 44d |  |  | 1136h | 576h |
| 32 | 7.1.1 | CCB2004 in Periph software | 5d? | 2004-03-29 A | 2004-04-02 A | 100% |  |  | start no earlier than 2004-03-29 | Geurts; Tumanov | 80h | 80h |
| 33 | 7.1.2 | TMB2004 in Periph software | 5d? | 2004-03-29 A | 2004-04-02 A | 100% |  |  | finish no earlier than 2004-04-02 | Geurts; Tumanov; Zheng | 120h | 120h |
| 34 | 7.1.3 | Develop cosmic time-in procedures for Periph Crate | 15d? | 2004-04-05 A | 2004-04-23 A | 100% |  |  | start no earlier than 2004-04-05 | Geurts; Tumanov | 240h | 240h |
| 35 | 7.1.4 | Develop data archive procedure | 1d? | 2004-04-05 A | 2004-04-05 A | 100% |  |  |  | Geurts | 8h | 8h |
| 36 | 7.1.5 | Fix end-of-run procedure to fully stop | 1d? | 2004-04-05 | 2004-04-05 |  |  | 76d |  |  |  |  |
| 37 | 7.1.6 | Filter to remove 2 bytes from data format | 8d? | 2004-04-05 A | 2004-04-14 A | 100% |  |  | finish no earlier than 2004-04-14 | Geurts; Durkin | 128h | 128h |
| 38 | 7.1.7 | Interface to run database | 35d? | 2004-04-05 | 2004-05-17 |  |  | 44d | finish no earlier than 2004-05-17 | Kotov; Vorobiev | 560h |  |
| 39 | 7.1.8 | automatic run number increment | 15d? | 2004-05-03 | 2004-05-17 |  |  | 44d | finish no earlier than 2004-05-17 |  |  |  |
| 40 | 7.1.9 | Run Control spread across multiple computers | 13d? | 2004-05-05 | 2004-05-17 |  |  | 44d | finish no earlier than 2004-05-17 |  |  |  |
| 41 | 7.2 | **Track-Finder Software Tasks** | 49d? | 2004-04-07 A | 2004-06-07 | 28% | 35.07d? | 28d |  |  | 1280h | 456h |
| 42 | 7.2.1 | Update to XDAQ2 in TF communication (use old HAL) | 10d? | 2004-04-12 A | 2004-04-23 A | 100% |  |  | finish no earlier than 2004-04-23 | Stoeck | 80h | 80h |
| 43 | 7.2.2 | CCB2004 in TF software | 10d? | 2004-04-12 A | 2004-04-23 A | 100% |  |  | finish no earlier than 2004-04-23 | Stoeck; Gray; Park; Scurlock | 320h | 320h |
| 44 | 7.2.3 | Partition TTC control to separate crate | 2d? | 2004-04-07 A | 2004-04-08 A | 100% |  |  | finish no earlier than 2004-04-08 | Stoeck | 16h | 16h |
| 45 | 7.2.4 | Port TF software to cmsdaq02 | 5d? | 2004-04-12 A | 2004-04-16 A | 100% |  |  | finish no earlier than 2004-04-16 | Stoeck | 40h | 40h |
| 46 | 7.2.5 | Log SP data standalone to disk | 15d | 2004-05-03 | 2004-05-17 |  |  | 44d | finish no earlier than 2004-05-17 | Scurlock; Uvarov | 240h |  |
| 47 | 7.2.6 | Event building with SP and DDU | 25d? | 2004-05-09 | 2004-06-07 |  |  | 28d | start no earlier than 2004-05-09 | Scurlock | 200h |  |
| 48 | 7.2.7 | Interface to run database | 10d? | 2004-05-08 | 2004-05-17 |  |  | 44d | finish no earlier than 2004-05-17 | Acosta; Gray; Kotov | 240h |  |
| 49 | 7.2.8 | MPC->SP PRBS test feature in TFGUI, TF crate | 9d? | 2004-05-09 | 2004-05-17 |  |  | 44d | finish no earlier than 2004-05-17 | Gray | 72h |  |
| 50 | 7.2.9 | MPC->SP PRBS test between PC and TF crate | 9d? | 2004-05-09 | 2004-05-17 |  |  | 44d | start no earlier than 2004-05-09 | Gray | 72h |  |
| 51 | 7.3 | **Firmware development** | 35d? | 2004-04-05 A | 2004-05-17 | 37% | 21.96d? | 44d |  |  | 640h | 238.4h |
| 52 | 7.3.1 | SP data format | 35d? | 2004-04-05 A | 2004-05-17 | 14% | 30d? | 44d | finish no earlier than 2004-05-17 | Uvarov | 280h | 40h |
| 53 | 7.3.2 | ALCT firmware for ghost cancellation | 35d? | 2004-04-05 A | 2004-05-17 | 71% | 10.2d? | 44d | finish no earlier than 2004-05-17 | Madorsky | 280h | 198.4h |
| 54 | 7.3.3 | Geometry offset to SR LUTs | 10d? | 2004-05-08 | 2004-05-17 |  |  | 44d | finish no earlier than 2004-05-17 | Acosta | 80h |  |

| ID | WBS | Task | Duration | Start | Finish | Predecessors | Complete | Remaining | Total slack | Free slack | Constraint | Resources | Work | Actual work |
| --- | --- | --- | --- | --- | --- | --- | --- | --- | --- | --- | --- | --- | --- | --- |
| 55 | 7.4 | **Simulation tasks** | 56d? | 2004-04-05 A | 2004-06-14 |  | 24% | 42.66d? | 23d |  |  |  | 712h | 132h |
| 56 | 7.4.1 | Set up test beam geometry | 36.25d | 2004-04-05 A | 2004-06-14 |  | 46% | 19.75d | 23d |  | finish no earlier than 2004-06-14 | Case; Cox | 448h | 132h |
| 57 | 7.4.2 | interface from raw data to ORCA | 33d? | 2004-05-06 | 2004-06-14 |  |  |  | 23d |  | finish no earlier than 2004-06-14 | Wilkinson | 264h |  |
| 58 | 7.5 | **Monitoring development** | 56d? | 2004-04-05 A | 2004-06-14 |  | 45% | 30.66d? | 23d |  |  |  | 1296h | 420h |
| 59 | 7.5.1 | SP monitoring program, TFGUI | 35d? | 2004-04-05 A | 2004-05-17 A |  | 100% |  |  |  | finish no earlier than 2004-05-17 | Gray | 280h | 280h |
| 60 | 7.5.2 | SP monitoring program, Root | 35d? | 2004-04-05 A | 2004-05-17 |  | 50% | 17.5d? | 44d |  | finish no earlier than 2004-05-17 | Scurlock | 280h | 140h |
| 61 | 7.5.3 | Test CSC monitoring scheme | 46d? | 2004-04-19 | 2004-06-14 |  |  |  | 23d |  | finish no earlier than 2004-06-14 | Korytov; Pakhotin | 736h |  |
| 62 | 7.6 | **DCS development** | 35d? | 2004-04-05 | 2004-05-17 |  |  |  | 44d |  |  |  | 280h |  |
| 63 | 7.6.1 | test HV and LV DCS monitoring and control | 35d? | 2004-04-05 | 2004-05-17 |  |  |  | 44d |  | start no earlier than 2004-04-05 | Sytnik | 280h |  |
| 64 | 7.7 | **Analysis framework** | 33d? | 2004-04-07 | 2004-05-17 |  |  |  | 44d |  |  |  | 528h |  |
| 65 | 7.7.1 | Program to compare SP and DDU trig data | 33d? | 2004-04-07 | 2004-05-17 |  |  |  | 44d |  | finish no earlier than 2004-05-17 | Acosta; Gray | 528h |  |
| 66 | 7.8 | **CSC Tasks** | 61d? | 2004-04-05 A | 2004-06-21 |  | 66% | 20.48d? | 18d |  |  |  | 1104h | 728h |
| 67 | 7.8.1 | Construct ME1/2 stand | 34d | 2004-04-05 A | 2004-05-16 A |  | 100% |  |  |  |  | Y.Wook [97.1%] | 264h | 264h |
| 68 | 7.8.2 | Construct ME 1/1 stand | 34d? | 2004-04-05 A | 2004-05-16 A |  | 100% |  |  |  |  | Dubna [97.1%] | 264h | 264h |
| 69 | 7.8.3 | Move ME n/2 chambers to X5A | 1d | 2004-05-12 | 2004-05-12 |  |  |  | 40d | 0d | start no earlier than 2004-05-12 | Levchenko | 8h |  |
| 70 | 7.8.4 | Move ME 1/1 to X5A | 1d | 2004-05-12 | 2004-05-12 |  |  |  | 49d |  | start no earlier than 2004-05-12 | Dubna | 8h |  |
| 71 | 7.8.5 | Move ME 1/2 to X5A | 1d | 2004-05-12 | 2004-05-12 |  |  |  | 49d |  | start no earlier than 2004-05-12 | Levchenko | 8h |  |
| 72 | 7.8.6 | Move all boxes to X5A | 1d | 2004-05-12 | 2004-05-12 |  |  |  | 47d | 0d | finish no earlier than 2004-05-12 | Levchenko | 8h |  |
| 73 | 7.8.7 | Modify gas system for new chambers | 5d | 2004-05-10 | 2004-05-14 |  |  |  | 47d |  | start no earlier than 2004-05-10 | Levchenko | 40h |  |
| 74 | 7.8.8 | Hook up gas | 2d | 2004-05-13 | 2004-05-14 | 69 |  |  | 40d | 0d | start no earlier than 2004-05-12 | Levchenko | 16h |  |
| 75 | 7.8.9 | Flush chambers | 5d | 2004-05-15 | 2004-05-19 | 74 |  |  | 41d | 0d | start no earlier than 2004-05-12 | Levchenko | 40h |  |
| 76 | 7.8.10 | Install HV and LV | 1d | 2004-05-13 | 2004-05-13 | 72 |  |  | 48d |  |  | Levchenko | 8h |  |
| 77 | 7.8.11 | Install ISR FAST site setup | 1d? | 2004-05-13 | 2004-05-13 | 69 |  |  | 47d | 0d |  | Levchenko | 8h |  |
| 78 | 7.8.12 | FAST noise and conectivity test | 1d? | 2004-05-14 | 2004-05-14 | 69, 77 |  |  | 47d |  |  | Levchenko | 8h |  |
| 79 | 7.8.13 | FAST chamber plateau test | 1d? | 2004-05-20 | 2004-05-20 | 75 |  |  | 41d |  |  | Levchenko | 8h |  |
| 80 | 7.8.14 | Construct LV cables | 25d? | 2004-04-05 A | 2004-05-07 A |  | 100% |  |  |  | start no earlier than 2004-04-05 | Lusin | 200h | 200h |
| 81 | 7.8.15 | Test trigger scintillators | 6d? | 2004-05-06 | 2004-05-11 |  |  |  | 44d | 0d | finish no earlier than 2004-05-11 | Roberts | 48h |  |
| 82 | 7.8.16 | Set up NIM trigger logic | 6d? | 2004-05-12 | 2004-05-17 | 81 |  |  | 44d |  |  | Roberts | 48h |  |
| 83 | 7.8.17 | Installation of RPC | 6d? | 2004-06-07 | 2004-06-14 |  |  |  | 23d |  | start no earlier than 2004-06-07 | RPC | 48h |  |
| 84 | 7.8.18 | RPC electronics tested | 6d? | 2004-06-14 | 2004-06-21 |  |  |  | 18d |  | finish no earlier than 2004-06-21 | RPC | 48h |  |
| 85 | 7.8.19 | set up computer network | 1d | 2004-05-13 | 2004-05-13 | 72 |  |  | 48d |  | start no earlier than 2004-05-12 | Geurts | 8h |  |
| 86 | 7.8.20 | install crates and racks | 2d | 2004-05-13 | 2004-05-14 | 72 |  |  | 47d |  | start no earlier than 2004-05-12 | Stoeck | 16h |  |

| ID | WBS | Task | Type | Duration | Start | Finish | Predecessors | Complete | Remaining | Total slack | Free slack | Constraint | Resources | Work | Actual work |
| --- | --- | --- | --- | --- | --- | --- | --- | --- | --- | --- | --- | --- | --- | --- | --- |
| 87 | 8 | **Shipping schedule** |  | 21d? | 2004-04-12 A | 2004-05-08 |  | 67% | 7d? | 53d |  |  | Acosta | 168h | 112h |
| 88 | 8.1 | 2 x 9U VME crates |  | 7d? | 2004-04-12 A | 2004-04-20 A |  | 100% |  |  |  | finish no earlier than 2004-04-20 |  |  |  |
| 89 | 8.2 | Tear down UF test stand | milestone | 0d | 2004-04-30 A | 2004-04-30 A |  | 100% |  |  |  | start no earlier than 2004-04-30 |  |  |  |
| 90 | 8.3 | acosta1 PC |  | 7d | 2004-04-30 A | 2004-05-08 | 89 | 50% | 3.5d | 53d |  | start no earlier than 2004-04-26 |  |  |  |
| 91 | 8.4 | geurts1 PC |  | 7d | 2004-04-30 A | 2004-05-08 | 89 | 50% | 3.5d | 53d |  | start no earlier than 2004-04-26 |  |  |  |
| 92 | 9 | **Beam Tasks** |  | 27d? | 2004-05-16 | 2004-06-21 |  |  |  | 19d |  |  |  | 136h |  |
| 93 | 9.1 | Time-in 2 large CSC's with CCB/2001/TMB2001 |  | 2d | 2004-05-16 | 2004-05-17 |  |  |  | 34d | 0d | start no earlier than 2004-05-16 | von der Mey; Gilmore; Geurts | 48h |  |
| 94 | 9.2 | Run "UFMay04" on 2 CSC's with CCB2001/TMB2001 |  | 2d | 2004-05-18 | 2004-05-19 | 93 |  |  | 34d | 0d | finish no earlier than 2004-05-18 | Geurts | 16h |  |
| 95 | 9.3 | Same but add CCB2004 |  | 2d? | 2004-05-20 | 2004-05-21 | 94 |  |  | 34d | 0d | finish no earlier than 2004-05-20 | Geurts | 16h |  |
| 96 | 9.4 | Same but add TMB2004 |  | 2d? | 2004-05-24 | 2004-05-25 | 95 |  |  | 34d | 0d | start no earlier than 2004-05-21 | Geurts | 16h |  |
| 97 | 9.5 | Download new ALCT firmware, check ghosts |  | 1d? | 2004-05-26 | 2004-05-26 | 96 |  |  | 33d | 0d |  | Acosta | 8h |  |
| 98 | 9.6 | Add ME1/1 to read out |  | 2d | 2004-05-27 | 2004-05-28 | 97 |  |  | 33d | 0d |  | Geurts | 16h |  |
| 99 | 9.7 | Add ME1/2 to read out |  | 2d | 2004-05-31 | 2004-06-01 | 98 |  |  | 33d |  |  | Geurts | 16h |  |
| 100 | 9.8 | Logged Data with iron absorber, muon | milestone | 0d | 2004-06-21 | 2004-06-21 |  |  |  | 19d |  | start no earlier than 2004-06-21 |  |  |  |
| 101 | 9.9 | Logged Data with iron absorber, pion | milestone | 0d | 2004-06-21 | 2004-06-21 |  |  |  | 19d |  | start no earlier than 2004-06-21 |  |  |  |
| 102 | 9.10 | Logged data with peripheral crate | milestone | 0d | 2004-06-21 | 2004-06-21 |  |  |  | 19d |  | start no earlier than 2004-06-21 |  |  |  |
| 103 | 9.11 | Logged data with SP | milestone | 0d | 2004-06-21 | 2004-06-21 |  |  |  | 19d |  | start no earlier than 2004-06-21 |  |  |  |
| 104 | 9.12 | Event-built logged data | milestone | 0d | 2004-06-21 | 2004-06-21 |  |  |  | 19d |  | start no earlier than 2004-06-21 |  |  |  |
| 105 | 9.13 | Logged data with 2 Peripheral crates | milestone | 0d | 2004-06-21 | 2004-06-21 |  |  |  | 19d |  | start no earlier than 2004-06-21 |  |  |  |
